# vdfs_prog_20030603

Schedule from MS Project, 2002-12-30 to 2005-01-03, scheduled back from the finish, A marks actual dates.
vista data flow system
CASU

## Calendars

- Standard: Mon-Fri 08:00-12:00, 13:00-17:00; Sat-Sun off.

## Schedule

| ID | WBS | Task | Type | Duration | Start | Finish | Predecessors | Complete | Remaining | Baseline start | Baseline finish | Baseline duration | Total slack | Free slack | Constraint | Text1 |
| --- | --- | --- | --- | --- | --- | --- | --- | --- | --- | --- | --- | --- | --- | --- | --- | --- |
| 1 | 1 | **Quarterly Reviews** |  | 461d? | 2003-03-31 | 2005-01-03 |  |  |  |  |  |  | 65d | 0d | as late as possible |  |
| 2 | 1.1 | Quarterly Review | milestone | 1d? | 2003-03-31 | 2003-03-31 |  |  |  |  |  |  | 63d | 0d | start no later than 2003-03-31 |  |
| 3 | 1.2 | Quarterly Review | milestone | 1d? | 2003-07-01 | 2003-07-01 |  |  |  |  |  |  | 129d | 0d | start no later than 2003-07-01 |  |
| 4 | 1.3 | Quarterly Review | milestone | 1d? | 2003-10-01 | 2003-10-01 |  |  |  |  |  |  | 195d | 0d | start no later than 2003-10-01 |  |
| 5 | 1.4 | Quarterly Review | milestone | 1d? | 2004-01-01 | 2004-01-01 |  |  |  |  |  |  | 263d | 0d | start no later than 2004-01-01 |  |
| 6 | 1.5 | Quarterly Review | milestone | 1d? | 2004-04-01 | 2004-04-01 |  |  |  |  |  |  | 326d | 0d | start no later than 2004-04-01 |  |
| 7 | 1.6 | Quarterly Review | milestone | 1d? | 2004-07-01 | 2004-07-01 |  |  |  |  |  |  | 391d | 0d | start no later than 2004-07-01 |  |
| 8 | 1.7 | Quarterly Review | milestone | 1d? | 2004-10-01 | 2004-10-01 |  |  |  |  |  |  | 457d | 0d | start no later than 2004-10-01 |  |
| 9 | 1.8 | Quarterly Review | milestone | 1d? | 2005-01-01 | 2005-01-03 |  |  |  |  |  |  | 523d | 0d | start no later than 2005-01-01 |  |
| 10 | 2 | **Management and Defenition of Responsibilities** |  | 523d? | 2003-01-01 A | 2004-12-31 |  | 52% | 248.48d? | 2003-01-01 | 2003-12-31 | 261d | 0d |  | as late as possible |  |
| 11 | 2.1 | Report to VISTA, UKIDSS, JAC, ATC, WFAP, GSC |  | 26.15mo | 2003-01-01 A | 2004-12-31 |  | 50% | 13.07mo | 2003-01-01 | 2003-01-01 | 0mo | 0d |  | finish no later than 2004-12-31 | 1.1 |
| 12 | 2.2 | Interface Control Document between CASU and JAC |  | 13.05mo | 2003-01-01 A | 2003-12-31 |  | 50% | 6.53mo | 2003-12-31 | 2003-12-31 | 0mo | 0d |  | finish no later than 2004-01-01 | 1.2 |
| 13 | 2.3 | Interface Control Document between CASU and WFAU |  | 6.5mo | 2003-01-01 A | 2003-07-01 |  | 50% | 3.25mo | 2003-06-30 | 2003-06-30 | 0mo | 0d |  | finish no later than 2003-07-01 | 1.3 |
| 14 | 2.4 | Define data structures and FITS headers |  | 6.5mo | 2003-01-01 A | 2003-07-01 |  | 50% | 3.25mo | 2003-06-30 | 2003-06-30 | 0mo | 0d |  | finish no later than 2003-07-01 | 1.4 |
| 15 | 2.5 | Define observing protocols |  | 6.5mo | 2003-01-01 A | 2003-07-01 A |  | 100% |  | 2003-12-31 | 2003-12-31 | 0mo |  |  | finish no later than 2003-07-01 | 1.5 |
| 16 | 2.6 | Liaise with UKIDSS and JAC on observing strategy |  | 13.05mo | 2003-01-01 A | 2003-12-31 |  | 50% | 6.53mo | 2003-01-01 | 2003-01-01 | 0mo | 0d |  | finish no later than 2003-12-31 | 1.6 |
| 17 | 2.7 | Liaise with UKIDSS and JAC on survey planning |  | 13.05mo | 2003-01-01 A | 2003-12-31 |  | 50% | 6.53mo | 2003-01-01 | 2003-01-01 | 0mo | 0d |  | finish no later than 2003-12-31 | 1.7 |
| 18 | 2.8 | Liaise with UKIDSS and JAC on survey progress database |  | 19.6mo | 2003-01-01 A | 2004-07-01 |  | 50% | 9.8mo | 2003-01-01 | 2003-01-01 | 0mo | 0d |  | finish no later than 2004-07-01 | 1.8 |
| 19 | 2.9 | System Documentation |  | 523d? | 2003-01-01 A | 2004-12-31 |  | 50% | 261.5d? |  |  |  | 0d |  | finish no later than 2004-12-31 | 1.9 |
| 20 | 3 | ICD between CASU and JAC | milestone | 1d? | 2003-12-31 | 2003-12-31 | 12 |  |  |  |  |  | -1d | 0d | start no later than 2003-12-31 | D1a |
| 21 | 4 | ICD between CASU and WFAU | milestone | 1d? | 2003-10-01 | 2003-10-01 | 13 |  |  |  |  |  | 65d | 0d | start no later than 2003-10-01 | D1b |
| 22 | 5 | Fits headers and data structures defention document | milestone | 1d? | 2003-07-01 | 2003-07-01 | 14 |  |  |  |  |  | -1d | 0d | finish no later than 2003-07-01 | D1c |
| 23 | 6 | **ESO VISTA software deliverables and documentation** |  | 523d? | 2003-01-01 A | 2004-12-31 |  | 27% | 380.87d? | 2003-01-01 | 2004-12-31 | 523d? | 0d |  | as late as possible |  |
| 24 | 6.1 | DFS user requirements document |  | 238d? | 2003-01-01 A | 2003-11-28 |  | 55% | 107.5d? | 2003-01-01 | 2004-12-31 | 523d? | 0d |  | finish no later than 2003-12-31 | 2.1 |
| 25 | 6.2 | Data reduction specification |  | 238d? | 2003-01-01 A | 2003-11-28 |  | 10% | 214.2d? |  |  |  | 0d |  | finish no later than 2003-12-31 | 2.2 |
| 26 | 6.3 | Calibration plan document for ESO |  | 238d? | 2003-01-01 A | 2003-11-28 |  | 50% | 119d? |  |  |  | 0d |  | finish no later than 2003-12-31 | 2.3 |
| 27 | 6.4 | Specification of calibration procedures for ESO |  | 261d? | 2003-01-01 A | 2003-12-31 |  | 10% | 234.9d? |  |  |  | 0d |  | finish no later than 2003-12-31 | 2.4 |
| 28 | 6.5 | Interface Control Document ESO/VPO |  | 262d? | 2004-01-01 A | 2004-12-31 |  | 50% | 131d? |  |  |  | 0d |  | finish no later than 2004-12-31 | 2.5 |
| 29 | 6.6 | Instrument specification and interface documents |  | 262d? | 2004-01-01 | 2004-12-31 |  |  |  |  |  |  | 263d | 0d | start no later than 2004-01-01 | 2.6 |
| 30 | 6.7 | Delivery software modules and ETC |  | 262d? | 2004-01-01 | 2004-12-31 |  |  |  |  |  |  | 263d | 0d | start no later than 2004-01-01 | 2.7 |
| 31 | 6.8 | Liaise with VISTA IR camera development team |  | 523d? | 2003-01-01 A | 2004-12-31 |  | 50% | 261.5d? |  |  |  | 0d |  | start no later than 2003-01-01 | 2.8 |
| 32 | 6.9 | Development of DQC measures |  | 262d? | 2004-01-01 | 2004-12-31 |  |  |  |  |  |  | 263d | 0d | start no later than 2004-01-01 | 2.9 |
| 33 | 7 | Calibration plan document | milestone | 1d? | 2003-12-01 | 2003-12-01 | 24 |  |  |  |  |  | 0d |  | start no later than 2003-12-01 | D2a |
| 35 | 8 | DFS user requirements document | milestone | 1d? | 2003-12-01 | 2003-12-01 | 26 |  |  |  |  |  | 0d |  | start no later than 2003-12-01 | D2c |

| ID | WBS | Task | Type | Duration | Start | Finish | Predecessors | Complete | Remaining | Baseline start | Baseline finish | Baseline duration | Total slack | Free slack | Constraint | Text1 |
| --- | --- | --- | --- | --- | --- | --- | --- | --- | --- | --- | --- | --- | --- | --- | --- | --- |
| 36 | 9 | **Pipeline Infrastructure and Progress Monitoring Tools** |  | 523d? | 2003-01-01 A | 2004-12-31 |  | 34% | 346.74d? | 2003-01-01 | 2004-12-31 | 523d? | 0d |  | as late as possible |  |
| 37 | 9.1 | Interactive tools for running pipeline |  | 132d? | 2003-06-30 A | 2003-12-30 | 38 | 50% | 66d? | 2003-07-01 | 2004-06-30 | 262d? | 0d |  | finish no later than 2003-12-31 | 3.1 |
| 38 | 9.2 | High level scripts to interrogate headers |  | 129d? | 2003-01-01 A | 2003-06-30 |  | 50% | 64.5d? | 2003-01-01 | 2003-06-30 | 129d? | 0d |  | finish no later than 2003-06-30 | 3.2 |
| 39 | 9.3 | Develop automatic progression of results to WWW pages |  | 262d? | 2003-10-01 A | 2004-09-30 | 38 | 50% | 131d? | 2003-10-01 | 2004-09-30 | 262d? | 0d |  | finish no later than 2004-09-30 | 3.3 |
| 40 | 9.4 | Automate checks to spot failures of pipeline |  | 262d? | 2003-10-01 A | 2004-09-30 | 38 | 10% | 235.8d? | 2003-10-01 | 2004-09-30 | 262d? | 0d |  | finish no later than 2004-09-30 | 3.4 |
| 41 | 9.5 | Tools for fixing problem datasets |  | 262d? | 2004-01-01 | 2004-12-31 |  |  |  | 2004-01-01 | 2004-12-31 | 262d? | 263d | 0d | start no later than 2004-01-01 | 3.5 |
| 42 | 9.6 | Group documentation for above |  | 447.38d? | 2003-04-16 A | 2004-12-31 |  | 50% | 223.69d? | 2003-04-16 | 2004-12-31 | 447.38d? | 0d |  | finish no later than 2004-12-31 | 3.6 |
| 43 | 9.7 | Reprocessing after bug fixes or improvements to algorithms |  | 23d? | 2004-12-01 | 2004-12-31 |  |  |  | 2004-12-01 | 2004-12-31 | 23d? | 502d | 0d | start no later than 2004-12-01 | 3.7 |
| 44 | 10 | Deliver pipeline V1.0 | milestone | 1d? | 2003-12-31 | 2003-12-31 | 37 |  |  |  |  |  | 0d |  | finish no later than 2003-12-31 | D3a |
| 45 | 11 | Deliver documentation for pipeline V1.0 | milestone | 1d? | 2003-12-31 | 2003-12-31 |  |  |  |  |  |  | 262d | 0d | finish no later than 2003-12-31 | D3b |
| 46 | 12 | **Set up and Manage Raw Science Archive** |  | 525d? | 2002-12-30 | 2004-12-31 |  |  |  | 2003-10-01 | 2004-12-31 | 328d? | 0d |  | as late as possible |  |
| 47 | 12.1 | Extend current UKIRT archive to cope with WFCAM |  | 262d? | 2002-12-30 | 2003-12-30 |  |  |  | 2003-10-01 | 2004-12-31 | 328d? | 0d |  | finish no later than 2004-09-30 | 4.1 |
| 48 | 12.2 | Ingest and verify WFCAM data |  | 262d? | 2004-01-01 | 2004-12-31 |  |  |  | 2004-01-01 | 2004-12-31 | 262d? | 263d | 0d | finish no later than 2004-12-31 | 4.2 |
| 49 | 13 | Create Raw Science Archive | milestone | 1d? | 2003-12-31 | 2003-12-31 | 47 |  |  |  |  |  | 0d |  | finish no later than 2003-12-31 | D4a |
| 50 | 14 | **Set up and Manage Data Processing System Hardware** |  | 523d? | 2003-01-01 A | 2004-12-31 |  | 17% | 435.92d? | 2003-01-01 | 2004-12-31 | 523d? | 263d | 0d | as late as possible |  |
| 51 | 14.1 | Investigate alternatives (benchmarking, reliability etc) |  | 195d? | 2003-01-01 A | 2003-09-30 |  | 50% | 97.5d? | 2003-01-01 | 2003-09-30 | 195d? | 0d |  | finish no later than 2003-09-30 | 5.1 |
| 52 | 14.2 | Buy hardware and install software |  | 132d? | 2003-06-30 A | 2003-12-30 |  | 50% | 66d? | 2003-07-01 | 2003-12-31 | 132d? | 0d |  | finish no later than 2003-12-31 | 5.2 |
| 53 | 14.3 | Integration and testing |  | 131d? | 2003-10-01 | 2004-03-31 |  |  |  | 2003-10-01 | 2004-03-31 | 131d? | 197d | 0d | finish no later than 2004-03-31 | 5.3 |
| 54 | 14.4 | Manage day-to-day, maintenance and upgrades |  | 262d? | 2004-01-01 | 2004-12-31 |  |  |  | 2004-01-01 | 2004-12-31 | 262d? | 263d | 0d | finish no later than 2004-12-31 | 5.4 |
| 55 | 14.5 | Hardware additions for further data processing system |  | 262d? | 2004-01-01 | 2004-12-31 |  |  |  | 2004-01-01 | 2004-12-31 | 262d? | 263d | 0d | finish no later than 2004-12-31 | 5.5 |
| 56 | 15 | Processing hardware in place | milestone | 1d? | 2003-12-31 | 2003-12-31 | 52 |  |  |  |  |  | 0d |  | finish no later than 2003-12-31 | D5a |
| 57 | 16 | **Run Standard Pipeline** |  | 262d? | 2004-01-01 | 2004-12-31 | 52 |  |  | 2004-01-01 | 2004-12-31 | 262d? | 131d | 0d | as late as possible |  |
| 58 | 16.1 | Ingest and verify data |  | 262d? | 2004-01-01 | 2004-12-31 |  |  |  | 2004-01-01 | 2004-12-31 | 262d? | 131d | 0d | finish no later than 2004-12-31 | 6.1 |
| 59 | 16.2 | Update master calibration frames |  | 262d? | 2004-01-01 | 2004-12-31 |  |  |  | 2004-01-01 | 2004-12-31 | 262d? | 131d | 0d | finish no later than 2004-12-31 | 6.2 |
| 60 | 16.3 | Monitor detector performance |  | 262d? | 2004-01-01 | 2004-12-31 |  |  |  | 2004-01-01 | 2004-12-31 | 262d? | 131d | 0d | finish no later than 2004-12-31 | 6.3 |
| 61 | 16.4 | Oversee standd processing |  | 262d? | 2004-01-01 | 2004-12-31 |  |  |  | 2004-01-01 | 2004-12-31 | 262d? | 131d | 0d | finish no later than 2004-12-31 | 6.4 |
| 62 | 16.5 | Astrometric calibration |  | 262d? | 2004-01-01 | 2004-12-31 |  |  |  | 2004-01-01 | 2004-12-31 | 262d? | 131d | 0d | finish no later than 2004-12-31 | 6.5 |
| 63 | 16.6 | Photometric calibration |  | 262d? | 2004-01-01 | 2004-12-31 |  |  |  | 2004-01-01 | 2004-12-31 | 262d? | 131d | 0d | finish no later than 2004-12-31 | 6.6 |
| 64 | 16.7 | Verify science products and monitor DQC measures |  | 262d? | 2004-01-01 | 2004-12-31 |  |  |  | 2004-01-01 | 2004-12-31 | 262d? | 131d | 0d | finish no later than 2004-12-31 | 6.7 |
| 65 | 16.8 | Monitor product data transfer to WFAU |  | 262d? | 2004-01-01 | 2004-12-31 |  |  |  | 2004-01-01 | 2004-12-31 | 262d? | 131d | 0d | finish no later than 2004-12-31 | 6.8 |
| 66 | 17 | Data flow to WFAU initiated | milestone | 1d? | 2004-01-01 | 2004-01-01 |  |  |  |  |  |  | 263d | 0d | finish no later than 2004-01-01 | D6a |

| ID | WBS | Task | Type | Duration | Start | Finish | Predecessors | Complete | Remaining | Baseline start | Baseline finish | Baseline duration | Total slack | Free slack | Constraint | Text1 |
| --- | --- | --- | --- | --- | --- | --- | --- | --- | --- | --- | --- | --- | --- | --- | --- | --- |
| 67 | 18 | **Development Work for Summit Pipeline** |  | 523d? | 2003-01-01 A | 2004-12-31 |  | 27% | 384.11d? | 2003-01-01 | 2004-12-31 | 523d? | 0d |  | as late as possible |  |
| 68 | 18.1 | Interface test pipelines to ORAC-DR |  | 129d? | 2003-01-01 A | 2003-06-30 |  | 50% | 64.5d? | 2003-01-01 | 2003-06-30 | 129d? | 0d |  | finish no later than 2003-06-30 | 7.1 |
| 69 | 18.2 | Implement WFCAM pipeline at summit |  | 132d? | 2003-07-01 A | 2003-12-31 | 68 | 10% | 118.8d? | 2003-07-01 | 2003-12-31 | 132d? | 0d |  | finish no later than 2003-12-31 | 7.2 |
| 70 | 18.3 | Documentation of interface |  | 261d? | 2003-01-01 A | 2003-12-31 |  | 50% | 130.5d? | 2003-01-01 | 2003-12-31 | 261d? | 0d |  | finish no later than 2003-12-31 | 7.3 |
| 71 | 18.4 | Upgrade and maintain summit pipeline |  | 262d? | 2004-01-01 | 2004-12-31 | 69 |  |  | 2004-01-01 | 2004-12-31 | 262d? | 0d |  | finish no later than 2004-12-31 | 7.4 |
| 72 | 19 | Deliver summit pipeline | milestone | 1d? | 2003-12-31 | 2003-12-31 |  |  |  |  |  |  | 262d | 0d | finish no later than 2003-12-31 | D7a |
| 73 | 20 | Deliver summit pipeline documentation | milestone | 1d? | 2003-12-31 | 2003-12-31 |  |  |  |  |  |  | 262d | 0d | finish no later than 2003-12-31 | D7b |
| 74 | 21 | **Development and Testing of Standard 2D Processing** |  | 457d? | 2003-01-01 A | 2004-09-30 |  | 38% | 283.44d? | 2003-01-01 | 2004-09-30 | 457d? | 66d | 0d | as late as possible |  |
| 75 | 21.1 | Further development of standard pipeline |  | 261d? | 2003-01-01 A | 2003-12-31 |  | 50% | 130.5d? |  |  |  | 0d |  | finish no later than 2003-12-31 | 8.1 |
| 76 | 21.2 | Liaison with WFCAM development team |  | 261d? | 2003-01-01 A | 2003-12-31 |  | 50% | 130.5d? | 2003-01-01 | 2003-12-31 | 261d? | 0d |  | finish no later than 2003-12-31 | 8.2 |
| 77 | 21.3 | Partake in planning commissioning observations |  | 197d? | 2003-04-01 A | 2003-12-31 |  | 50% | 98.5d? | 2003-04-01 | 2003-12-31 | 197d? | 0d |  | finish no later than 2003-12-31 | 8.3 |
| 78 | 21.4 | Participate directly in commissioning |  | 131d? | 2003-10-01 | 2004-03-31 |  |  |  | 2003-10-01 | 2004-03-31 | 131d? | 197d | 0d | finish no later than 2004-03-31 | 8.4 |
| 79 | 21.5 | Tuning pipeline during commissioning and after |  | 262d? | 2003-10-01 | 2004-09-30 |  |  |  | 2003-10-01 | 2004-09-30 | 262d? | 197d | 0d | finish no later than 2004-09-30 | 8.5 |
| 80 | 21.6 | Documentation of 2Dprocessing software |  | 261d? | 2003-01-01 A | 2003-12-31 |  | 50% | 130.5d? | 2003-01-01 | 2003-12-31 | 261d? | 0d |  | finish no later than 2003-12-31 | 8.6 |
| 81 | 21.7 | Comparsion between automated and manual data products |  | 261.38d? | 2003-04-01 A | 2004-06-30 |  | 50% | 130.69d? | 2003-04-01 | 2004-06-30 | 261.38d? | 0d |  | finish no later than 2004-06-30 | 8.7 |
| 82 | 22 | Complete 2D processing modules V1.0 | milestone | 1d? | 2004-01-01 | 2004-01-01 | 75, 76, 80 |  |  |  |  |  | 0d |  | start no later than 2004-01-01 | D8a |
| 83 | 23 | **Development and Testing of Standard Catalogue Products** |  | 523d? | 2003-01-01 A | 2004-12-31 |  | 47% | 275.37d? | 2003-01-01 | 2004-12-31 | 523d? | 0d |  | as late as possible |  |
| 84 | 23.1 | Add in new measures requested |  | 197d? | 2003-04-01 A | 2003-12-31 |  | 10% | 177.3d? | 2003-04-01 | 2003-12-31 | 197d? | 0d |  | finish no later than 2003-12-31 | 9.1 |
| 85 | 23.2 | Refine astrometric calibration model |  | 394d? | 2003-07-01 A | 2004-12-31 |  | 55% | 177.3d? | 2003-07-01 | 2004-12-31 | 394d? | 0d |  | finish no later than 2004-12-31 | 9.2 |
| 86 | 23.3 | Generate simulations of expectd data |  | 197d? | 2003-04-01 A | 2003-12-31 |  | 50% | 98.5d? | 2003-04-01 | 2003-12-31 | 197d? | 0d |  | finish no later than 2003-12-31 | 9.3 |
| 87 | 23.4 | Assess catalogue parameter reliability |  | 197d? | 2003-04-01 A | 2003-12-31 |  | 50% | 98.5d? | 2003-04-01 | 2003-12-31 | 197d? | 0d |  | finish no later than 2003-12-31 | 9.4 |
| 88 | 23.5 | Intercomparison of catalogue products with other packages |  | 523d? | 2003-01-01 A | 2004-12-31 |  | 50% | 261.5d? | 2003-01-01 | 2004-12-31 | 523d? | 0d |  | finish no later than 2004-12-31 | 9.5 |
| 89 | 23.6 | Completeness and error estimates |  | 459d? | 2003-04-01 A | 2004-12-31 |  | 50% | 229.5d? | 2003-04-01 | 2004-12-31 | 459d? | 0d |  | finish no later than 2004-12-31 | 9.6 |
| 90 | 23.7 | Documentation of catalogue software and products |  | 261d? | 2003-01-01 A | 2003-12-31 |  | 50% | 130.5d? | 2003-01-01 | 2004-12-31 | 523d? | 0d |  | start no later than 2003-01-01 | 9.7 |
| 91 | 24 | Complete standard catalogue modules V1.0 | milestone | 1d? | 2004-01-01 | 2004-01-01 | 84, 86, 87, 90 |  |  |  |  |  | 0d |  | start no later than 2004-01-01 | D9a |

| ID | WBS | Task | Type | Duration | Start | Finish | Predecessors | Complete | Remaining | Baseline start | Baseline finish | Baseline duration | Total slack | Free slack | Constraint | Text1 |
| --- | --- | --- | --- | --- | --- | --- | --- | --- | --- | --- | --- | --- | --- | --- | --- | --- |
| 92 | 25 | **Set Up, Trial and Run Further Processing Software** |  | 394d? | 2003-07-01 | 2004-12-31 |  |  |  | 2003-01-01 | 2004-12-31 | 523d? | 131d | 0d | as late as possible | 10 |
| 93 | 25.1 | Manage and run further processing stages |  | 262d? | 2004-01-01 | 2004-12-31 |  |  |  | 2004-01-01 | 2004-12-31 | 262d? | 263d | 0d | finish no later than 2004-12-31 | 10.1 |
| 94 | 25.2 | Development and assessment of PSF options 1,2 |  | 394d? | 2003-07-01 | 2004-12-31 |  |  |  | 2003-01-01 | 2004-12-31 | 523d? | 131d | 0d | start no later than 2003-07-01 | 10.2 |
| 95 | 25.3 | Develop 1D/2D PSF-deconvolved Sersic profile fits |  | 262d? | 2004-01-01 | 2004-12-31 |  |  |  | 2004-01-01 | 2004-12-31 | 262d? | 263d | 0d | finish no later than 2004-12-31 | 10.3 |
| 96 | 25.4 | Develop LSBG/nebulosity detection/parameterisation |  | 262d? | 2004-01-01 | 2004-12-31 |  |  |  | 2004-01-01 | 2004-12-31 | 262d? | 263d | 0d | finish no later than 2004-12-31 | 10.4 |
| 97 | 25.5 | Full iterative profile fitting for stellar images |  | 1d? | 2004-12-31 | 2004-12-31 |  |  |  | 2004-12-31 | 2004-12-31 | 1d? | 524d | 0d | as late as possible | 10.5 |
| 98 | 25.6 | Develop and optimise Bayesian image classification |  | 1d? | 2004-12-31 | 2004-12-31 |  |  |  | 2004-12-31 | 2004-12-31 | 1d? | 524d | 0d | as late as possible | 10.6 |
| 99 | 25.7 | Modelling and simulations of further processing steps |  | 197d? | 2004-04-01 | 2004-12-31 |  |  |  | 2004-04-01 | 2004-12-31 | 197d? | 328d | 0d | finish no later than 2004-12-31 | 10.7 |
| 100 | 26 | Deliver 2D PSF and Sersic fitting applications | milestone | 1d? | 2004-12-31 | 2004-12-31 |  |  |  |  |  |  | 524d | 0d | as late as possible | D10a |
| 101 | 27 | **Photometric Standards and Calibraion** |  | 523d? | 2003-01-01 A | 2004-12-31 |  | 18% | 427.74d? | 2003-01-01 | 2004-12-31 | 523d? | 66d | 0d | as late as possible | 11 |
| 102 | 27.1 | Agree on primary standards |  | 261d? | 2003-01-01 A | 2003-12-31 |  | 50% | 130.5d? | 2003-01-01 | 2003-12-31 | 261d? | 0d |  | finish no later than 2003-12-31 | 11.1 |
| 103 | 27.2 | Choose secondary standard fields |  | 261d? | 2003-01-01 A | 2003-12-31 |  | 50% | 130.5d? | 2003-01-01 | 2003-12-31 | 261d? | 0d |  | finish no later than 2003-12-31 | 11.2 |
| 104 | 27.3 | Take part in comissioning observations |  | 65d? | 2004-01-01 | 2004-03-31 | 102, 103 |  |  | 2004-01-01 | 2004-03-31 | 65d? | 0d |  | finish no later than 2004-03-31 | 11.3 |
| 105 | 27.4 | Reduce data, compute zero points and colour equations |  | 130d? | 2004-01-01 | 2004-06-30 | 102, 103 |  |  | 2004-01-01 | 2004-06-30 | 130d? | 0d |  | finish no later than 2004-06-30 | 11.4 |
| 106 | 27.5 | Update maintain and extend secondary standards system |  | 192d? | 2004-04-01 | 2004-12-24 | 102, 103 |  |  | 2004-04-01 | 2004-12-24 | 192d? | 65d | 0d | finish no later than 2004-12-24 | 11.5 |
| 107 | 27.6 | Investigate photometric calibration field systematics |  | 196d? | 2004-01-01 | 2004-09-30 | 102, 103 |  |  | 2004-01-01 | 2004-09-30 | 196d? | 0d |  | finish no later than 2004-09-30 | 11.6 |
| 108 | 27.7 | Assess extinction monitoring methods |  | 328d? | 2003-10-01 | 2004-12-31 |  |  |  | 2003-10-01 | 2004-12-31 | 328d? | 197d | 0d | finish no later than 2004-12-31 | 11.7 |
| 109 | 28 | Allocate primary and secondary standard stars/fields | milestone | 131d? | 2004-01-01 | 2004-07-01 | 102, 103 |  |  |  |  |  | 0d |  | start no later than 2004-01-01 | D11a |
| 110 | 29 | Photometric calibration and colour equations | milestone | 1d? | 2004-07-01 | 2004-07-01 | 102, 103, 104, 105 |  |  |  |  |  | 0d |  | start no later than 2004-07-01 | D11b |
| 111 | 30 | **Further Development of DQC Measures** |  | 457d? | 2003-01-01 A | 2004-09-30 |  | 15% | 390.49d? | 2003-01-01 | 2004-09-30 | 457d? | 68d | 0d | as late as possible | 12 |
| 112 | 30.1 | Develop extra systematic noise measures |  | 262d? | 2003-07-01 | 2004-06-30 |  |  |  | 2003-07-01 | 2004-06-30 | 262d? | 131d | 0d | finish no later than 2004-06-30 | 12.1 |
| 113 | 30.2 | Refine curent measures for WFCAM/VISTA data |  | 262d? | 2003-10-01 | 2004-09-30 |  |  |  | 2003-10-01 | 2004-09-30 | 262d? | 197d | 0d | finish no later than 2004-09-30 | 12.2 |
| 114 | 30.3 | Implement 2MASS -c.f. for throughput measures |  | 257d? | 2003-01-01 A | 2004-06-28 |  | 50% | 128.5d? | 2003-01-01 | 2004-06-28 | 257d? | 0d |  | finish no later than 2004-06-28 | 12.3 |
| 115 | 30.4 | Master calibration frames for detector monitoring |  | 326d? | 2003-01-01 A | 2004-03-31 |  | 10% | 293.4d? | 2003-01-01 | 2004-03-31 | 326d? | 0d |  | finish no later than 2004-03-31 | 12.4 |

| ID | WBS | Task | Type | Duration | Start | Finish | Predecessors | Complete | Remaining | Baseline start | Baseline finish | Baseline duration | Total slack | Free slack | Constraint | Text1 |
| --- | --- | --- | --- | --- | --- | --- | --- | --- | --- | --- | --- | --- | --- | --- | --- | --- |
| 116 | 31 | **Co-located List Driven Photometry** |  | 523d? | 2003-01-01 A | 2004-12-31 |  | 30% | 366.58d? | 2003-01-01 | 2004-12-31 | 523d? | 262d | 0d | as late as possible | 13 |
| 117 | 31.1 | Test methods for master catalogue generation |  | 129d? | 2003-01-01 A | 2003-06-30 |  | 50% | 64.5d? | 2003-01-01 | 2003-06-30 | 129d? | 0d |  | finish no later than 2003-06-30 | 13.1 |
| 118 | 31.2 | Develop basic WCS-based list driven photometer |  | 261d? | 2003-01-01 A | 2003-12-31 |  | 50% | 130.5d? | 2003-01-01 | 2003-12-31 | 261d? | 0d |  | finish no later than 2003-12-31 | 13.2 |
| 119 | 31.3 | Externally driven WCS photometry and define parameter set |  | 262d? | 2004-01-01 | 2004-12-31 |  |  |  | 2004-01-01 | 2004-12-31 | 262d? | 263d | 0d | finish no later than 2004-12-31 | 13.3 |
| 120 | 32 | Deliver list driven photometer | milestone | 1d? | 2003-12-31 | 2003-12-31 | 118 |  |  |  |  |  | -1d | 0d | finish no later than 2003-12-31 | D13a |
| 121 | 33 | **Stacking and Mosaicing** |  | 523d? | 2003-01-01 A | 2004-12-31 |  | 33% | 349.78d? | 2003-01-01 | 2004-12-31 | 523d? | 263d | 0d | as late as possible | 14 |
| 122 | 33.1 | Develop benchmark simple stacking/mosaicing framework |  | 129d? | 2003-01-01 A | 2003-06-30 A |  | 100% |  | 2003-01-01 | 2003-06-30 | 129d? |  |  | finish no later than 2003-06-30 | 14.1 |
| 123 | 33.2 | Nearest neighbour algorithm |  | 131d? | 2003-04-01 A | 2003-09-30 A |  | 100% |  | 2003-04-01 | 2003-09-30 | 131d? |  |  | finish no later than 2003-09-30 | 14.2 |
| 124 | 33.3 | More sophisticated rejection dealing with pixellation |  | 262d? | 2003-10-01 | 2004-09-30 |  |  |  | 2003-10-01 | 2004-09-30 | 262d? | 197d | 0d | finish no later than 2004-09-30 | 14.3 |
| 125 | 33.4 | Stacking with optimum weighting and defect rejection |  | 262d? | 2004-01-01 | 2004-12-31 |  |  |  | 2004-01-01 | 2004-12-31 | 262d? | 263d | 0d | finish no later than 2004-12-31 | 14.4 |
| 126 | 33.5 | Advanced stacking/image restoration for variable PSF |  | 1d? | 2004-12-31 | 2004-12-31 |  |  |  | 2004-12-31 | 2004-12-31 | 1d? | 524d | 0d | as late as possible | 14.5 |
| 127 | 34 | Deliver basic stacker and mosaicer | milestone | 1d? | 2003-09-30 | 2003-09-30 | 122, 123 |  |  |  |  |  | -1d | 0d | finish no later than 2003-09-30 | D14 |
| 128 | 35 | **Continuum Subtraction and Basic Difference Imaging** |  | 457d? | 2003-01-01 A | 2004-09-30 |  | 44% | 254.49d? | 2003-01-01 | 2004-09-30 | 457d? | 65.38d | 0d | as late as possible | 15 |
| 129 | 35.1 | Simple WCS-based subtraction techniques |  | 196d? | 2003-04-01 A | 2004-06-30 |  | 50% | 98d? | 2003-04-01 | 2004-06-30 | 196d? | 0d |  | start no later than 2003-04-01 | 15.1 |
| 130 | 35.2 | Investigate and apply different interpolation methods |  | 326d? | 2003-01-01 A | 2004-07-01 |  | 50% | 163d? | 2003-01-01 | 2004-07-01 | 326d? | 0d |  | finish no later than 2004-07-01 | 15.2 |
| 131 | 35.3 | Develop adaptive kernel matching option |  | 1d | 2004-09-30 | 2004-09-30 |  |  |  | 2004-09-30 | 2004-09-30 | 1d | 458d | 0d | finish no later than 2004-10-01 | 15.3 |
| 132 | 35.4 | Transient event detection |  | 66d? | 2004-07-01 | 2004-09-30 |  |  |  | 2004-07-01 | 2004-09-30 | 66d? | 393d | 0d | finish no later than 2004-09-30 | 15.4 |
| 133 | 36 | **Interpolation Techniques and PSF Modelling** |  | 523d? | 2003-01-01 A | 2004-12-31 |  | 19% | 424.04d? | 2003-01-01 | 2004-12-31 | 523d? | 0d |  | as late as possible | 16 |
| 134 | 36.1 | Investigate alternative interpolation/PSF schemes |  | 129d? | 2003-01-01 A | 2003-06-30 |  | 50% | 64.5d? | 2003-01-01 | 2003-06-30 | 129d? | 0d |  | finish no later than 2003-06-30 | 16.1 |
| 135 | 36.2 | Implications for different stacking methods |  | 132d? | 2003-07-01 | 2003-12-31 |  |  |  | 2003-07-01 | 2003-12-31 | 132d? | 131d | 0d | finish no later than 2003-12-31 | 16.2 |
| 136 | 36.3 | Implications for deriving catalogues and parameters |  | 261d? | 2003-01-01 A | 2003-12-31 |  | 50% | 130.5d? | 2003-01-01 | 2003-12-31 | 261d? | 0d |  | finish no later than 2003-12-31 | 16.3 |
| 137 | 36.4 | Oversampled PSF generation per detector |  | 523d? | 2003-01-01 A | 2004-12-31 |  | 10% | 470.7d? | 2003-01-01 | 2004-12-31 | 523d? | 0d |  | finish no later than 2004-12-31 | 16.4 |
| 138 | 36.5 | Develop oversampled spatially varying PSF model |  | 262d? | 2003-12-31 | 2004-12-30 |  |  |  | 2004-01-01 | 2004-12-31 | 262d? | 262d | 0d | finish no later than 2004-12-31 | 16.5 |
| 139 | 37 | Deliver PSF photometer | milestone | 1d? | 2004-12-31 | 2004-12-31 | 134, 135, 136, 137, 138 |  |  |  |  |  | -1d | 0d | as late as possible | D16a |
